# planning self hôtel dieu

Schedule from MS Project, 2026-06-15 to 2026-11-26, 7 hours a day.
CHU

## Calendars

- Standard: Mon-Fri 09:00-12:00, 14:00-18:00; Sat-Sun off.

## Resources

| Resource | Group |
| --- | --- |
| LOT 1.1 | GO SO |
| LOT 2 | CFO CFA SSI |
| LOT 3 | CVCD PLB |
| LOT 4 | FM |
| LOT 1.2 |  |
| LOT 1.3 |  |
| LOT 1.4 |  |
| LOT 1.5 |  |
| LOT 1.6 |  |
| ATMOE |  |
| MOA |  |
| 3 |  |

## Schedule

| ID | WBS | Task | Type | Duration | Start | Finish | Predecessors | Baseline start | Baseline finish | Baseline duration | Total slack | Free slack | Constraint | Resources | Work | Référence CCTP |
| --- | --- | --- | --- | --- | --- | --- | --- | --- | --- | --- | --- | --- | --- | --- | --- | --- |
| 1 | 1 | **P2413 _ contruction d'une Unité d'Isolement spécifique (U.I.S.)** |  | 119d? | 2026-06-15 | 2026-11-26 |  | 2026-01-01 | 2031-05-15 | 1401d | 0d |  |  |  | 4585h |  |
| 2 | 1.1 | Notification marché de travaux | milestone | 0d | 2026-06-15 | 2026-06-15 |  |  |  |  | 76d |  |  |  |  |  |
| 3 | 1.2 | **Installation de chantier** |  | 2d | 2026-06-15 | 2026-06-16 |  |  |  |  | 116d |  |  |  | 28h |  |
| 4 | 1.2.1 | Production PIC |  | 1d | 2026-06-15 | 2026-06-15 |  |  |  |  | 73d | 0d | start no earlier than 2026-06-15 | LOT 1.1 | 7h | 4.1 |
| 5 | 1.2.2 | Installation des locaux base vie |  | 1d | 2026-06-16 | 2026-06-16 | 4 |  |  |  | 74d |  |  | LOT 1.1 | 7h | 4.1 |
| 6 | 1.2.3 | Raccordement électrique base vie et coffret de chantier |  | 1d | 2026-06-16 | 2026-06-16 | 4 |  |  |  | 74d |  |  | LOT 2 | 7h | 3.2 |
| 7 | 1.2.4 | Signalétique chantier |  | 1d | 2026-06-16 | 2026-06-16 | 4 |  |  |  | 73d | 0d |  | LOT 1.1 | 7h | 4.1 |
| 8 | 1.3 | **Etude d'exécution** |  | 10d | 2026-06-15 | 2026-06-26 |  |  |  |  | 109d |  |  |  | 420h |  |
| 9 | 1.3.1 | CVC chambre d'isolement |  | 3d | 2026-06-15 | 2026-06-17 |  |  |  |  | 71d | 0d |  | LOT 3 | 21h |  |
| 10 | 1.3.2 | Validation EXE CVC chambre d'isolement |  | 1d | 2026-06-18 | 2026-06-18 | 9 |  |  |  | 71d | 0d |  | ATMOE | 7h |  |
| 11 | 1.3.3 | Commande fournisseur matériel CVC chambre d'osolement |  | 1d | 2026-06-19 | 2026-06-19 | 10 |  |  |  | 71d |  |  | LOT 3 | 7h |  |
| 12 | 1.3.4 | Second oeuvre |  | 5d | 2026-06-15 | 2026-06-19 |  |  |  |  | 71d |  | start no earlier than 2026-06-15 | LOT 1.2; LOT 1.3; LOT 1.4; LOT 1.5; LOT 1.6 | 175h |  |
| 13 | 1.3.5 | CFO CFA SSI |  | 5d | 2026-06-15 | 2026-06-19 |  |  |  |  | 71d |  |  | LOT 2 | 35h |  |
| 14 | 1.3.6 | Plomberie |  | 10d | 2026-06-15 | 2026-06-26 |  |  |  |  | 66d |  |  | LOT 3 | 70h |  |
| 15 | 1.3.7 | Gros Œuvre |  | 5d | 2026-06-15 | 2026-06-19 |  |  |  |  | 71d |  |  | LOT 1.1 | 35h |  |
| 16 | 1.3.8 | CVC autres zones |  | 5d | 2026-06-15 | 2026-06-19 |  |  |  |  | 71d |  |  | LOT 3 | 35h |  |
| 17 | 1.3.9 | Fluides médicaux |  | 5d | 2026-06-15 | 2026-06-19 |  |  |  |  | 66d | 0d |  | LOT 4 | 35h |  |
| 18 | 1.4 | **Phase 1_ création des salles de bain** |  | 29d | 2026-06-15 | 2026-07-23 |  | 2026-01-01 | 2030-11-14 | 1271d | 0d |  |  |  | 1197h |  |
| 19 | 1.4.1 | Consignation électrique |  | 1d | 2026-06-17 | 2026-06-17 | 7 |  |  |  | 73d |  |  | LOT 2 | 7h | 3.2 |
| 20 | 1.4.2 | Protection étanche des terminaux aérauliques |  | 1d | 2026-06-15 | 2026-06-15 |  |  |  |  | 0d |  |  | LOT 3 | 7h | 4.2 |
| 21 | 1.4.3 | Protections verticales |  | 2d | 2026-06-16 | 2026-06-17 | 20 | 2026-01-01 | 2026-07-15 | 140d | 73d |  |  | LOT 1.1 | 14h | 4.2 |
| 22 | 1.4.4 | Protection des sols |  | 2d | 2026-06-16 | 2026-06-17 | 20 | 2026-04-14 | 2026-05-14 | 23d | 0d |  |  | LOT 1.1 | 14h | 4.1 |
| 23 | 1.4.5 | Purge des points d'eau de la zone chantier |  | 5d | 2026-06-15 | 2026-06-19 |  |  |  |  | 71d |  |  | LOT 3 | 35h | 3.3 |
| 24 | 1.4.6 | Création d'ouverture dans cloison pour bloc porte |  | 1d | 2026-06-18 | 2026-06-18 | 22 |  |  |  | 101d | 0d |  | LOT 1.2 | 7h | 1.3.1.5 |
| 25 | 1.4.7 | F&P bloc porte type b nouvel accès chambres de gardes |  | 1d | 2026-06-19 | 2026-06-19 | 24 |  |  |  | 102d |  |  | LOT 1.4; LOT 1.2 | 14h | 1.3.1.3 |
| 26 | 1.4.8 | Mise en peinture bloc porte |  | 2d | 2026-06-19 | 2026-06-22 | 24 |  |  |  | 101d | 0d |  | LOT 1.5 | 14h | 2.4.2 |
| 27 | 1.4.9 | Mise en service nouvel accès chambres de garde | milestone | 0d | 2026-06-22 | 2026-06-22 | 26 |  |  |  | 70d |  |  |  |  |  |
| 28 | 1.4.10 | Dépose rail lève malade |  | 1d | 2026-06-18 | 2026-06-18 | 22 |  |  |  | 103d |  |  | MOA | 7h |  |
| 29 | 1.4.11 | Dépose sol emprise salle de bain |  | 2d | 2026-06-18 | 2026-06-19 | 22 |  |  |  | 102d |  |  | LOT 1.1 | 14h | 4.3 |
| 30 | 1.4.12 | Depose équipements électriques & adaptation éclairage |  | 1d | 2026-06-18 | 2026-06-18 | 22 |  |  |  | 103d |  |  | LOT 2 | 7h | 4.9 du lot 1.1 |
| 31 | 1.4.13 | Dépose équipements divers |  | 1d | 2026-06-18 | 2026-06-18 | 22 |  |  |  | 103d |  |  | LOT 1.1 | 7h | 4.12 |
| 32 | 1.4.14 | Isolement des réseaux de plomberie par la pose de vanne 1/4tr |  | 2d | 2026-06-18 | 2026-06-19 | 22 |  |  |  | 102d |  |  | LOT 3 | 14h | 4.2 |
| 33 | 1.4.15 | Depose des équipements sanitaires et réseaux associés (bras mort) |  | 1d | 2026-06-18 | 2026-06-18 | 22 |  |  |  | 103d |  |  | LOT 3 | 7h | 3.2&3.5 |
| 34 | 1.4.16 | Dépose cloison et bouchement d'ouverture |  | 2d | 2026-06-18 | 2026-06-19 | 22 |  |  |  | 102d |  |  | LOT 1.1; LOT 1.2 | 28h | 1.3.1.6 & 4.8 |
| 35 | 1.4.17 | Depose soigneuse des menuiseries intérieures, yc porte automatique |  | 1d | 2026-06-18 | 2026-06-18 | 22 | 2026-05-14 | 2026-05-14 | 0d | 103d |  |  | LOT 1.1 | 7h | 4.4 |
| 36 | 1.4.18 | Dépose cloisons |  | 1d | 2026-06-18 | 2026-06-18 | 22 |  |  |  | 103d |  |  | LOT 1.1 | 7h | 4.8 |
| 37 | 1.4.19 | Dépose papiers peints |  | 2d | 2026-06-18 | 2026-06-19 | 22 |  |  |  | 0d |  |  | LOT 1.5 | 14h | 2.3.1 |
| 38 | 1.4.20 | Dépose des prises et réseaux terminaux associés |  | 1d | 2026-06-22 | 2026-06-22 | 22, 37 |  |  |  | 0d |  |  | LOT 4 | 7h | 2.4.2 |
| 39 | 1.4.21 | Réalisation de carrotage pour réseau EU salle de bain |  | 3d | 2026-06-18 | 2026-06-22 | 22 |  |  |  | 101d |  |  | LOT 3 | 21h | 5.3.2 |
| 40 | 1.4.22 | F&P cloisons |  | 6d | 2026-06-23 | 2026-06-30 | 38 |  |  |  | 0d |  |  | LOT 1.2 | 42h | 1.3.1.1 |
| 41 | 1.4.23 | Raccord de chappe |  | 2d | 2026-06-25 | 2026-06-26 | 40SS+2d |  |  |  | 97d |  |  | LOT 1.5 | 14h | 1.2.1.1 |
| 42 | 1.4.24 | F&P appel malade salle de bain |  | 3d | 2026-06-26 | 2026-06-30 | 40FS-3d |  |  |  | 64d |  |  | LOT 2 | 21h | 4.1.8 |
| 43 | 1.4.25 | F&P terminaux SSI (IA, DI) |  | 3d | 2026-06-26 | 2026-06-30 | 40FS-3d |  |  |  | 64d |  |  | LOT 2 | 21h | 4.1.9 |
| 44 | 1.4.26 | F&P terminaux CFA (RJ45) |  | 4d | 2026-06-23 | 2026-06-26 | 38 |  |  |  | 97d |  |  | LOT 2 | 28h | 4.1.4 |
| 45 | 1.4.27 | F&P équipements CFA CA à raccorder sur UTL créée en zone phase 2, interphone, wifi |  | 2d | 2026-06-26 | 2026-06-29 | 40FS-3d |  |  |  | 65d |  |  | LOT 2 | 14h | 4.1.5&4.1.7&4.1.10 |
| 46 | 1.4.28 | F&P luminaires |  | 5d | 2026-06-26 | 2026-07-02 | 40FS-3d |  |  |  | 0d |  |  | LOT 2 | 35h | 3.8.4 & 3.8.5 |
| 47 | 1.4.29 | F&P équipements CFO |  | 6d | 2026-06-23 | 2026-06-30 | 38 |  |  |  | 95d |  |  | LOT 2 | 42h | 3.8.2;3.7 |
| 48 | 1.4.30 | F&P réseaux EF/ECS yc réseaux pour appreil sanitaire salle de soins phase 3 |  | 4d | 2026-06-23 | 2026-06-26 | 38 |  |  |  | 95d | 0d |  | LOT 3 | 28h | 3.4 |
| 49 | 1.4.31 | F&P gaine technique salle de bain |  | 2d | 2026-06-29 | 2026-06-30 | 48 |  |  |  | 95d |  |  | LOT 1.2; LOT 1.4 | 28h | 1.3.2 & 1.5 |
| 50 | 1.4.32 | F&P renfort gaine technique |  | 2d | 2026-06-29 | 2026-06-30 | 48 |  |  |  | 95d |  |  | LOT 1.4 | 14h | 1.9 |
| 51 | 1.4.33 | F&P porte coulissante salle de bain |  | 2d | 2026-06-29 | 2026-06-30 | 40FS-2d |  |  |  | 64d |  |  | LOT 1.4 | 14h | 1.3.5.1 |
| 52 | 1.4.34 | Chape pour salle de bain |  | 3d | 2026-06-30 | 2026-07-02 | 40FS-1d |  |  |  | 55d | 0d |  | LOT 1.5 | 21h | 1.2.1.1 |
| 53 | 1.4.35 | Ragréage salle de bain |  | 3d | 2026-07-02 | 2026-07-06 | 52FS-1d |  |  |  | 55d | 0d |  | LOT 1.5 | 21h | 1.2.2.1 |
| 54 | 1.4.36 | F&P appareils sanitares et autres accessoires |  | 5d | 2026-07-09 | 2026-07-15 | 53, 77FS-3d |  |  |  | 53d |  |  | LOT 3 | 35h | 3.7 |
| 55 | 1.4.37 | Revêtement sol et mur salle de bain |  | 5d | 2026-07-03 | 2026-07-09 | 53FS-2d |  |  |  | 57d |  |  | LOT 1.5 | 35h | 1.3.2&1.3.3 |
| 56 | 1.4.38 | Réfection des pleinthes en PVC SAS entrée |  | 1d | 2026-06-26 | 2026-06-26 | 40FS-3d |  |  |  | 66d |  |  | LOT 1.5 | 7h | 1.3.3 |
| 57 | 1.4.39 | F&P bloc porte DAS SAS entrée |  | 2d | 2026-06-29 | 2026-06-30 | 40FS-2d |  |  |  | 64d |  |  | LOT 1.4; LOT 1.2 | 28h | 1.3.3.3&1.3.1.8 |
| 58 | 1.4.40 | F&P bloc porte sur bras débrayable réserve entrée |  | 2d | 2026-06-29 | 2026-06-30 | 40FS-2d |  |  |  | 64d |  |  | LOT 1.4; LOT 1.2 | 28h | 1.3.2.8&1.3.1.8 |
| 59 | 1.4.41 | P porte automatique type A1 récupérée |  | 2d | 2026-06-29 | 2026-06-30 | 40FS-2d |  |  |  | 61d | 0d |  | LOT 1.6 | 14h | 1.2.1 |
| 60 | 1.4.42 | Travaux de raccordement sur primaires des nouvelles distributions GM |  | 5d | 2026-06-22 | 2026-06-26 | 17 |  |  |  | 66d |  |  | LOT 4 | 35h | 2.4.3 |
| 61 | 1.4.43 | F&P réseaux secondaire en faux plafond |  | 5d | 2026-06-18 | 2026-06-24 | 22 |  |  |  | 61d | 0d |  | LOT 4 | 35h | 2.4.7 |
| 62 | 1.4.44 | F&P Armoire ultime secours |  | 5d | 2026-06-18 | 2026-06-24 | 22 |  |  |  | 98d | 0d |  | LOT 4 | 35h | 2.4.4 |
| 63 | 1.4.45 | Essais mise en service |  | 1d | 2026-06-25 | 2026-06-25 | 62 |  |  |  | 98d |  |  | LOT 4 | 7h | 2.4.11 |
| 64 | 1.4.46 | Etiquetage réseaux GM |  | 1d | 2026-06-25 | 2026-06-25 | 61 |  |  |  | 98d |  |  | LOT 4 | 7h | 2.4.1 |

| ID | WBS | Task | Type | Duration | Start | Finish | Predecessors | Total slack | Free slack | Resources | Work | Référence CCTP |
| --- | --- | --- | --- | --- | --- | --- | --- | --- | --- | --- | --- | --- |
| 65 | 1.4.47 | **création nouveau réseau secondaire FM hors zone chantier** |  | 8d | 2026-06-24 | 2026-07-06 |  | 103d |  |  | 70h |  |
| 66 | 1.4.47.1 | Fermeture 2 chambres | milestone | 0d | 2026-06-24 | 2026-06-24 | 61 | 99d |  |  |  |  |
| 67 | 1.4.47.2 | Protection étanche des terminaux aérauliques |  | 1d | 2026-06-25 | 2026-06-25 | 61 | 98d |  | LOT 3 | 7h | 4.2 |
| 68 | 1.4.47.3 | Protections verticales |  | 1d | 2026-06-25 | 2026-06-25 | 61 | 98d |  | LOT 1.1 | 7h | 4.2 |
| 69 | 1.4.47.4 | Protection des sols |  | 1d | 2026-06-25 | 2026-06-25 | 61 | 91d | 0d | LOT 1.1 | 7h | 4.1 |
| 70 | 1.4.47.5 | F&P réseaux secondaire en faux plafond |  | 3d | 2026-06-26 | 2026-06-30 | 69 | 91d | 0d | LOT 4 | 21h | 2.4.7 |
| 71 | 1.4.47.6 | F&P vannes de sectionnement en limite de zone chantier phase 3 |  | 1d | 2026-07-01 | 2026-07-01 | 70 | 91d | 0d | LOT 4 | 7h | 2.4.6 |
| 72 | 1.4.47.7 | Essais mise en service |  | 1d | 2026-07-02 | 2026-07-02 | 71 | 91d | 0d | LOT 4 | 7h | 2.4.11 |
| 73 | 1.4.47.8 | Nettoyage |  | 1d | 2026-07-03 | 2026-07-03 | 72 | 91d | 0d | LOT 1.5 | 7h | 2.5 |
| 74 | 1.4.47.9 | Bionettoyage |  | 1d | 2026-07-06 | 2026-07-06 | 73 | 91d |  | MOA | 7h |  |
| 75 | 1.4.48 | Création ouverture pour F&P trappe |  | 4d | 2026-06-18 | 2026-06-23 | 22 | 100d |  | LOT 1.2; LOT 1.4 | 56h | 1.3.1.4&1.5 |
| 76 | 1.4.49 | Pafond salle de bain |  | 3d | 2026-07-03 | 2026-07-07 | 53FS-2d | 90d |  | LOT 1.2 | 21h | 1.4.2.3 |
| 77 | 1.4.50 | Mise en peinture bloc porte, trappes, mur |  | 7d | 2026-07-03 | 2026-07-13 | 46 | 0d |  | LOT 1.5 | 49h | 2.4 |
| 78 | 1.4.51 | F&P protections murales |  | 3d | 2026-07-01 | 2026-07-03 | 59 | 92d |  | LOT 1.4 | 21h | 1.7.1 |
| 79 | 1.4.52 | Nettoyage phase 1 |  | 2d | 2026-07-14 | 2026-07-15 | 77 | 0d |  | LOT 1.5 | 14h | 2.5 |
| 80 | 1.4.53 | OPR |  | 1d | 2026-07-16 | 2026-07-16 | 79 | 0d |  | ATMOE; MOA | 14h |  |
| 81 | 1.4.54 | Levée des réserves |  | 1d | 2026-07-17 | 2026-07-17 | 80 | 0d |  | LOT 1.1; LOT 1.2; LOT 1.3; LOT 1.4; LOT 1.5; LOT 1.6; LOT 2; LOT 3; LOT 4 | 63h |  |
| 82 | 1.4.55 | Nettoyage phase 2 |  | 1d | 2026-07-20 | 2026-07-20 | 81 | 0d |  | LOT 1.5 | 7h | 2.5 |
| 83 | 1.4.56 | Réception partielle phase 1 | milestone | 0d | 2026-07-22 | 2026-07-22 | 84, 82 | 79d |  | LOT 1.1; LOT 1.2; LOT 1.3; LOT 1.4 |  |  |
| 84 | 1.4.57 | Bionettoyage |  | 2d | 2026-07-21 | 2026-07-22 | 82 | 0d |  | MOA | 14h |  |
| 85 | 1.4.58 | Déménagement & libération emprise phase 2 |  | 1d | 2026-07-23 | 2026-07-23 | 84 | 0d |  | MOA | 7h |  |
| 86 | 1.5 | **Phase 2_Création chambre d'isolement spécifique** |  | 43d | 2026-07-24 | 2026-09-22 |  | 0d |  |  | 2121h |  |
| 87 | 1.5.1 | Consignation électrique |  | 1d | 2026-07-24 | 2026-07-24 | 85 | 77d |  | LOT 2 | 7h | 3.2 |
| 88 | 1.5.2 | Protection étanche des terminaux aérauliques |  | 1d | 2026-07-24 | 2026-07-24 | 85 | 77d |  | LOT 3 | 7h | 4.2 |
| 89 | 1.5.3 | Protections verticales |  | 2d | 2026-07-24 | 2026-07-27 | 85 | 76d |  | LOT 1.1 | 14h | 4.2 |
| 90 | 1.5.4 | Protection des sols |  | 2d | 2026-07-24 | 2026-07-27 | 85 | 0d |  | LOT 1.1 | 14h | 4.1 |
| 91 | 1.5.5 | Purge des points d'eau de la zone chantier |  | 1d | 2026-07-24 | 2026-07-24 | 85 | 77d |  | LOT 3 | 7h | 3.3 |
| 92 | 1.5.6 | Dépose faux plafond |  | 3d | 2026-07-28 | 2026-07-30 | 90 | 56d | 0d | LOT 1.1 | 21h | 4.7 |
| 93 | 1.5.7 | Dépose installations électriques |  | 1d | 2026-07-28 | 2026-07-28 | 90 | 75d |  | LOT 2 | 7h | 4.9.1 du lot 1.1 |
| 94 | 1.5.8 | Dépose et adaptations installations CVC yc radiateurs |  | 5d | 2026-07-28 | 2026-08-03 | 90 | 71d |  | LOT 3 | 35h | 4.2&4..5.2.1 |
| 95 | 1.5.9 | Dépose équipements divers |  | 1d | 2026-07-28 | 2026-07-28 | 90 | 75d |  | LOT 1.1 | 7h | 4.12 |
| 96 | 1.5.10 | Dépose des prises et réseaux terminaux associés |  | 2d | 2026-07-28 | 2026-07-29 | 90 | 74d |  | LOT 4 | 14h | 2.4.2 |
| 97 | 1.5.11 | Dépose cloison |  | 4d | 2026-07-28 | 2026-07-31 | 90 | 0d |  | LOT 1.1 | 28h | 4.8 |
| 98 | 1.5.12 | Dépose soigneuse menuiseries |  | 1d | 2026-07-28 | 2026-07-28 | 90 | 75d |  | LOT 1.1 | 7h | 4.4.2 |
| 99 | 1.5.13 | Dépose soigneuse porte automatique |  | 1d | 2026-07-28 | 2026-07-28 | 90 | 75d |  | LOT 1.1 | 7h | 4.4.3 |
| 100 | 1.5.14 | Depose des équipements sanitaires et réseaux associés (bras mort) |  | 4d | 2026-07-28 | 2026-07-31 | 90 | 72d |  | LOT 3 | 28h | 3.2&3.5 |
| 101 | 1.5.15 | Dépose papiers peints |  | 2d | 2026-07-28 | 2026-07-29 | 90 | 74d |  | LOT 1.5 | 14h | 2.3.1 |
| 102 | 1.5.16 | Modification d'ouverture |  | 2d | 2026-07-28 | 2026-07-29 | 90 | 69d | 0d | LOT 1.2 | 14h | 1.3.1.3 |
| 103 | 1.5.17 | Bouchement d'ouverture |  | 4d | 2026-07-28 | 2026-07-31 | 90 | 72d |  | LOT 1.2 | 28h | 1.3.1.6 |
| 104 | 1.5.18 | Création d'ouverture dans cloison pour bloc porte |  | 3d | 2026-07-28 | 2026-07-30 | 90 | 71d | 0d | LOT 1.2 | 21h | 1.3.1.5 |
| 105 | 1.5.19 | F&P bloc porte type l, type A5, type j |  | 2d | 2026-07-31 | 2026-08-03 | 104 | 71d |  | LOT 1.4; LOT 1.2; LOT 1.6 | 42h | 1.3.3&1.3.4&1.2.5.6&1.3.1.8 |
| 106 | 1.5.20 | Dépose sol souple |  | 3d | 2026-07-30 | 2026-08-03 | 97FS-2d | 0d |  | LOT 1.1 | 21h | 4.6.1 |
| 107 | 1.5.21 | Raccord de chappe |  | 3d | 2026-08-03 | 2026-08-05 | 106FS-1d | 0d |  | LOT 1.5 | 21h | 1.2.1.1 |
| 108 | 1.5.22 | Réalisation de réservations spécifiques |  | 3d | 2026-07-28 | 2026-07-30 | 90 | 73d |  | LOT 1.1 | 21h | 5.3.8 |
| 109 | 1.5.23 | F&P réseaux EF/ECS et adaptation réseaux EF/ECS existants |  | 5d | 2026-07-28 | 2026-08-03 | 90 | 71d |  | LOT 3 | 35h | 3.4 |
| 110 | 1.5.24 | F&P réseaux EC/EG depuis R+2 et adaptation réseaux EC/EG existants |  | 5d | 2026-07-28 | 2026-08-03 | 90 | 71d |  | LOT 3 | 35h | 4.4.2 |
| 111 | 1.5.25 | F&P réseaux secondaire en faux plafond |  | 5d | 2026-07-31 | 2026-08-06 | 92 | 61d | 0d | LOT 4 | 35h | 2.4.5 |
| 112 | 1.5.26 | Fourniture et pose prises gaines tête de lits |  | 3d | 2026-08-18 | 2026-08-20 | 92, 150FS-5d | 58d |  | LOT 4 | 21h | 2.4.2 |
| 113 | 1.5.27 | F&P support de bras d'anesthésie |  | 5d | 2026-07-31 | 2026-08-06 | 92 | 68d |  | MOA | 35h |  |

| ID | WBS | Task | Type | Duration | Start | Finish | Predecessors | Total slack | Free slack | Resources | Work | Référence CCTP |
| --- | --- | --- | --- | --- | --- | --- | --- | --- | --- | --- | --- | --- |
| 114 | 1.5.28 | **création nouveau réseau secondaire FM hors zone chantier - PHASE 2bis** |  | 7d | 2026-08-06 | 2026-08-17 |  | 73d |  |  | 168h |  |
| 115 | 1.5.28.1 | Fermeture 2 chambres | milestone | 0d | 2026-08-06 | 2026-08-06 | 111 | 68d |  |  |  |  |
| 116 | 1.5.28.2 | Protection étanche des terminaux aérauliques |  | 1d | 2026-08-07 | 2026-08-07 | 111 | 67d |  | LOT 3 | 7h | 4.2 |
| 117 | 1.5.28.3 | Protections verticales |  | 1d | 2026-08-07 | 2026-08-07 | 111 | 67d |  | LOT 1.1 | 7h | 4.2 |
| 118 | 1.5.28.4 | Protection des sols |  | 1d | 2026-08-07 | 2026-08-07 | 111 | 61d | 0d | LOT 1.1 | 7h | 4.1 |
| 119 | 1.5.28.5 | F&P réseaux secondaire en faux plafond |  | 3d | 2026-08-10 | 2026-08-12 | 118 | 62d | 0d | LOT 4 | 21h | 2.4.7 |
| 120 | 1.5.28.6 | F&P vannes de sectionnement en limite de zone chantier phase 3 |  | 1d | 2026-08-13 | 2026-08-13 | 119 | 63d |  | LOT 4 | 7h | 2.4.6 |
| 121 | 1.5.28.7 | Essais détanchéité |  | 1d | 2026-08-13 | 2026-08-13 | 119 | 75d |  | LOT 4 | 7h | 2.4.13 |
| 122 | 1.5.28.8 | F&P piquage réseaux EC/EG sur réseau secondaire |  | 4d | 2026-08-10 | 2026-08-13 | 118 | 63d |  | LOT 3 | 28h | 4.4.2 |
| 123 | 1.5.28.9 | Modification de l'AD ZC1.6-1 |  | 4d | 2026-08-10 | 2026-08-13 | 118 | 62d | 0d | LOT 2 | 28h | 3.6 |
| 124 | 1.5.28.10 | Mise à jour note de calcule AD ZC1.6-1 |  | 1d | 2026-08-14 | 2026-08-14 | 123 | 62d |  | LOT 2 | 7h | 3.5 |
| 125 | 1.5.28.11 | F&P porte automatique type A3 |  | 3d | 2026-08-10 | 2026-08-12 | 118 | 61d | 0d | LOT 1.6 | 21h | 1.2.3 |
| 126 | 1.5.28.12 | Pose chassis grillagé |  | 2d | 2026-08-12 | 2026-08-13 | 125FS-1d | 61d | 0d | LOT 1.4 | 14h | 1.3.6 |
| 127 | 1.5.28.13 | Nettoyage |  | 1d | 2026-08-14 | 2026-08-14 | 126, 119 | 61d | 0d | LOT 1.5 | 7h | 2.5 |
| 128 | 1.5.28.14 | Bionettoyage |  | 1d | 2026-08-17 | 2026-08-17 | 127 | 61d |  | MOA | 7h |  |
| 129 | 1.5.29 | F&P Armoire ultime secours |  | 5d | 2026-07-31 | 2026-08-06 | 92 | 56d | 0d | LOT 4 | 35h | 2.4.4 |
| 130 | 1.5.30 | F&P vannes de sectionnement |  | 2d | 2026-08-07 | 2026-08-10 | 129 | 56d | 0d | LOT 4 | 14h | 2.4.6 |
| 131 | 1.5.31 | Etiquetage réseaux GM |  | 1d | 2026-08-11 | 2026-08-11 | 130 | 56d | 0d | LOT 4 | 7h | 2.4.1 |
| 132 | 1.5.32 | F&P système d'alarme |  | 4d | 2026-08-12 | 2026-08-17 | 131 | 56d | 0d | LOT 4 | 28h | 2.4.11 |
| 133 | 1.5.33 | raccordement GM12 sur nouveau réseau primaire et secondaire selon phase §2.4.1 CCTP |  | 5d | 2026-08-18 | 2026-08-24 | 132 | 56d |  | LOT 4 | 35h | 2.4.1 |
| 134 | 1.5.34 | F&P cloisons |  | 10d | 2026-08-06 | 2026-08-19 | 107 | 0d |  | LOT 1.2 | 70h | 1.3.1.1 |
| 135 | 1.5.35 | Modification des faux plafonds |  | 3d | 2026-08-03 | 2026-08-05 | 102FS+2d | 69d |  | LOT 1.2 | 21h | 1.4.2.1 |
| 136 | 1.5.36 | F&P chassis vitrés bois |  | 5d | 2026-08-12 | 2026-08-18 | 134FS-6d | 60d |  | LOT 1.4 | 35h | 1.4 |
| 137 | 1.5.37 | P chassis récupéré sur bureau |  | 1d | 2026-08-12 | 2026-08-12 | 134FS-6d | 64d |  | LOT 1.2 | 7h | 1.3.1.7 |
| 138 | 1.5.38 | F&P gaine technique salle de bain |  | 2d | 2026-08-12 | 2026-08-13 | 134FS-6d | 63d |  | LOT 1.2; LOT 1.4 | 28h | 1.3.2 & 1.5 |
| 139 | 1.5.39 | F&P renfort gaine technique |  | 2d | 2026-08-12 | 2026-08-13 | 134FS-6d | 63d |  | LOT 1.4 | 14h | 1.9 |
| 140 | 1.5.40 | F&P bloc porte bois de la zone phase 2 |  | 7d | 2026-08-12 | 2026-08-20 | 134FS-6d | 42d | 0d | LOT 1.4; LOT 1.2 | 98h | 1.3 |
| 141 | 1.5.41 | Chape pour salle de bain |  | 1d | 2026-08-17 | 2026-08-17 | 134FS-3d, 140FS-5d | 60d | 0d | LOT 1.5 | 7h | 1.2.1.1 |
| 142 | 1.5.42 | Ragréage salle de bain |  | 1d | 2026-08-18 | 2026-08-18 | 141 | 60d |  | LOT 1.5 | 7h | 1.2.2.1 |
| 143 | 1.5.43 | F&P porte automatique de la zone phase 2 |  | 4d | 2026-08-18 | 2026-08-21 | 134FS-2d | 55d | 0d | LOT 1.6 | 28h | 1.2 |
| 144 | 1.5.44 | F&P plafond plaque de platre et trappe |  | 2d | 2026-08-24 | 2026-08-25 | 143 | 55d |  | LOT 1.2 | 14h | 1.4.1.1&1.4.1.2 |
| 145 | 1.5.45 | Remplacement trappe gaine technique local réserve |  | 1d | 2026-07-28 | 2026-07-28 | 90 | 75d |  | LOT 1.4 | 7h | 1.5 |
| 146 | 1.5.46 | F&P appel malade |  | 10d | 2026-08-11 | 2026-08-24 | 134FS-7d | 56d |  | LOT 2 | 70h | 4.1.8 |
| 147 | 1.5.47 | F&P terminaux SSI (IA, DI) |  | 10d | 2026-08-11 | 2026-08-24 | 134FS-7d | 56d |  | LOT 2 | 70h | 4.1.9 |
| 148 | 1.5.48 | F&P terminaux CFA (RJ45) yc besoins Phase 3 |  | 10d | 2026-08-11 | 2026-08-24 | 134FS-7d | 56d |  | LOT 2 | 70h | 4.1.4 |
| 149 | 1.5.49 | F&P équipements CFA CA, interphone, wifi yc compris besoins phase 3 |  | 10d | 2026-08-11 | 2026-08-24 | 134FS-7d | 56d |  | LOT 2 | 70h | 4.1.5&4.1.7&4.1.10 |
| 150 | 1.5.50 | F&P équipements CFO, yc départ spécifique CVC et gaine tête de lit |  | 10d | 2026-08-11 | 2026-08-24 | 134FS-7d | 56d | 0d | LOT 2 | 70h | 3.8.2;3.7 |
| 151 | 1.5.51 | F&P réseaux et équipements de régulation CVC depuis local CTA |  | 10d | 2026-08-11 | 2026-08-24 | 134FS-7d | 0d |  | LOT 3 | 70h | 4.5.3&4.7 |
| 152 | 1.5.52 | Renforcement étanchéité gaine |  | 2d | 2026-08-18 | 2026-08-19 | 151FS-5d | 59d |  | LOT 1.2 | 14h | 1.6.1.3 |
| 153 | 1.5.53 | Mise en peinture bloc porte, trappes, mur |  | 10d | 2026-08-20 | 2026-09-02 | 151FS-3d | 0d |  | LOT 1.5 | 70h | 2.4 |
| 154 | 1.5.54 | F&P faux plafond |  | 5d | 2026-08-24 | 2026-08-28 | 153FS-8d | 0d |  | LOT 1.2 | 35h | 1.4.2&1.4.3 |
| 155 | 1.5.55 | F&P luminaires |  | 2d | 2026-08-27 | 2026-08-28 | 154FS-2d | 52d |  | LOT 2 | 14h | 3.8 |
| 156 | 1.5.56 | Ragréage local CTA |  | 1d | 2026-08-21 | 2026-08-21 | 140 | 42d | 0d | LOT 1.5 | 7h | 1.2.2 |
| 157 | 1.5.57 | F&P sol souple local CTA |  | 1d | 2026-08-24 | 2026-08-24 | 156 | 42d | 0d | LOT 1.5 | 7h | 1.3 |
| 158 | 1.5.58 | Habillage mural acoustique local CTA |  | 1d | 2026-08-25 | 2026-08-25 | 157 | 42d | 0d | LOT 1.2 | 7h | 1.5 |
| 159 | 1.5.59 | F&P plateforme de répartition armoire de traitement d'air |  | 1d | 2026-08-26 | 2026-08-26 | 158 | 42d | 0d | LOT 1.1 | 7h | 5.3.9 |
| 160 | 1.5.60 | F&P équipements CVC et CFO local CTA |  | 8d | 2026-08-27 | 2026-09-07 | 159 | 42d | 0d | LOT 3 | 56h | 4.5.3&4.6 |
| 161 | 1.5.61 | Supervision, essais, mise en service |  | 5d | 2026-09-07 | 2026-09-11 | 160FS-1d | 42d |  | LOT 3 | 35h | 4.8&4.10&4.11 |
| 162 | 1.5.62 | Ragréage toutes zones |  | 3d | 2026-08-27 | 2026-08-31 | 154FS-2d | 0d |  | LOT 1.5 | 21h | 1.2.2 |
| 163 | 1.5.63 | F&P sol souple toutes zones |  | 3d | 2026-09-01 | 2026-09-03 | 162 | 0d |  | LOT 1.5 | 21h | 1.3 |
| 164 | 1.5.64 | F&P protection murale type decoclean |  | 3d | 2026-09-03 | 2026-09-07 | 151, 163FS-1d | 46d |  | LOT 1.4 | 21h | 1.7.1.1 |
| 165 | 1.5.65 | F&P protection type décochoc |  | 5d | 2026-09-04 | 2026-09-10 | 151, 163 | 0d |  | LOT 1.4 | 35h | 1.7.1 |
| 166 | 1.5.66 | Nettoyage phase 1&mise à blanc ZEM |  | 1d | 2026-09-11 | 2026-09-11 | 165 | 0d |  | LOT 1.5; MOA | 14h | 2.5 |
| 167 | 1.5.67 | Qualification ZEM |  | 7d | 2026-09-14 | 2026-09-22 | 166 | 35d |  | MOA | 49h |  |
| 168 | 1.5.68 | OPR |  | 2d | 2026-09-14 | 2026-09-15 | 166 | 0d |  | ATMOE; MOA | 28h |  |
| 169 | 1.5.69 | Levée des réserves |  | 1d | 2026-09-16 | 2026-09-16 | 168 | 0d |  | LOT 1.1; LOT 1.2; LOT 1.3; LOT 1.4; LOT 1.5; LOT 1.6; LOT 2; LOT 3; LOT 4 | 63h |  |
| 170 | 1.5.70 | Nettoyage phase 2 |  | 1d | 2026-09-17 | 2026-09-17 | 169 | 0d |  | LOT 1.5 | 7h | 2.5 |
| 171 | 1.5.71 | Réception partielle phase 2 | milestone | 0d | 2026-09-17 | 2026-09-17 | 170 | 0d |  | LOT 1.1; LOT 1.2; LOT 1.3; LOT 1.4 |  |  |
| 172 | 1.5.72 | Bionettoyage |  | 2d | 2026-09-18 | 2026-09-21 | 171 | 0d |  | MOA | 14h |  |
| 173 | 1.5.73 | Déménagement & libération emprise phase 3 |  | 1d | 2026-09-22 | 2026-09-22 | 172 | 0d |  | MOA | 7h |  |

| ID | WBS | Task | Type | Duration | Start | Finish | Predecessors | Total slack | Free slack | Resources | Work | Référence CCTP |
| --- | --- | --- | --- | --- | --- | --- | --- | --- | --- | --- | --- | --- |
| 174 | 1.6 | **Phase 3_Aménagement locaux supports** |  | 35d? | 2026-09-23 | 2026-11-10 |  | 0d |  |  | 819h |  |
| 175 | 1.6.1 | Consignation électrique |  | 1d | 2026-09-23 | 2026-09-23 | 173 | 46d |  | LOT 2 | 7h | 3.2 |
| 176 | 1.6.2 | Protection étanche des terminaux aérauliques |  | 1d | 2026-09-23 | 2026-09-23 | 173 | 46d |  | LOT 3 | 7h | 4.2 |
| 177 | 1.6.3 | Purge des points d'eau de la zone chantier |  | 1d? | 2026-09-23 | 2026-09-23 | 173 | 46d |  | LOT 3 | 7h | 3.3 |
| 178 | 1.6.4 | Protections verticales |  | 2d | 2026-09-23 | 2026-09-24 | 173 | 0d |  | LOT 1.1 | 14h | 4.2 |
| 179 | 1.6.5 | Protection des sols |  | 2d | 2026-09-25 | 2026-09-28 | 178 | 0d |  | LOT 1.1 | 14h | 4.1 |
| 180 | 1.6.6 | Démolition maçonnerie |  | 2d | 2026-09-29 | 2026-09-30 | 179 | 0d |  | LOT 1.1 | 14h | 4.11 |
| 181 | 1.6.7 | F&P bloc porte métallique |  | 1d | 2026-10-01 | 2026-10-01 | 180 | 0d |  | LOT 1.3 | 7h | 1.2.1 |
| 182 | 1.6.8 | Dépose faux plafond |  | 2d | 2026-10-02 | 2026-10-05 | 181 | 0d |  | LOT 1.1 | 14h | 4.7 |
| 183 | 1.6.9 | Dépose équipements divers |  | 2d | 2026-10-02 | 2026-10-05 | 181 | 34d | 0d | LOT 1.1 | 14h | 4.12 |
| 184 | 1.6.10 | Dépose soigneuse menuiseries yc chassis vitré |  | 2d | 2026-10-06 | 2026-10-07 | 183 | 34d | 0d | LOT 1.1 | 14h | 4.4.2 |
| 185 | 1.6.11 | Bouchement d'ouverture |  | 2d | 2026-10-08 | 2026-10-09 | 184 | 34d |  | LOT 1.2 | 14h | 1.3.1.6 |
| 186 | 1.6.12 | Depose des équipements sanitaires et réseaux associés (bras mort) |  | 2d | 2026-10-02 | 2026-10-05 | 181 | 38d |  | LOT 3 | 14h | 3.2&3.5 |
| 187 | 1.6.13 | Dépose et adaptations installations CVC yc radiateurs |  | 5d | 2026-10-02 | 2026-10-08 | 181 | 35d |  | LOT 3 | 35h | 4.2&4..5.2.1 |
| 188 | 1.6.14 | Dépose cloison |  | 3d | 2026-10-06 | 2026-10-08 | 182 | 0d |  | LOT 1.1 | 21h | 4.8 |
| 189 | 1.6.15 | Dépose sol souple |  | 4d | 2026-10-07 | 2026-10-12 | 188FS-2d | 0d |  | LOT 1.1 | 28h | 4.6.1 |
| 190 | 1.6.16 | Création d'ouverture dans cloison pour bloc porte |  | 3d | 2026-10-12 | 2026-10-14 | 189FS-1d | 19d |  | LOT 1.2 | 21h | 1.3.1.5 |
| 191 | 1.6.17 | Modification d'ouverture |  | 3d | 2026-10-12 | 2026-10-14 | 189FS-1d | 0d |  | LOT 1.2 | 21h | 1.3.1.3 |
| 192 | 1.6.18 | Raccord de chappe |  | 2d | 2026-10-15 | 2026-10-16 | 191 | 0d |  | LOT 1.5 | 14h | 1.2.1.1 |
| 193 | 1.6.19 | Dépose papiers peints |  | 3d | 2026-10-12 | 2026-10-14 | 189FS-1d | 19d |  | LOT 1.5 | 21h | 2.3.1 |
| 194 | 1.6.20 | F&P cloisons |  | 5d | 2026-10-19 | 2026-10-23 | 192 | 24d |  | LOT 1.2 | 35h | 1.3.1.1 |
| 195 | 1.6.21 | F&P bloc porte bois |  | 4d | 2026-10-19 | 2026-10-22 | 192 | 25d |  | LOT 1.4; LOT 1.2 | 56h | 1.3 |
| 196 | 1.6.22 | Adaptation réseaux EC/EG |  | 4d | 2026-10-19 | 2026-10-22 | 192 | 25d |  | LOT 3 | 28h | 4.4.2 |
| 197 | 1.6.23 | F&P réseaux EF/ECS |  | 4d | 2026-10-19 | 2026-10-22 | 192 | 21d | 0d | LOT 3 | 28h | 3.4 |
| 198 | 1.6.24 | Intégration supervision GTC |  | 4d | 2026-10-23 | 2026-10-28 | 197 | 21d |  | LOT 3 | 28h | 3.8 |
| 199 | 1.6.25 | F&P terminaux SSI (IA, DI) |  | 5d | 2026-10-19 | 2026-10-23 | 192 | 24d |  | LOT 2 | 35h | 4.1.9 |
| 200 | 1.6.26 | F&P terminaux CFA (RJ45) yc besoins Phase 3 |  | 5d | 2026-10-19 | 2026-10-23 | 192 | 24d |  | LOT 2 | 35h | 4.1.4 |
| 201 | 1.6.27 | F&P équipements CFA CA, interphone, wifi yc compris besoins phase 3 |  | 5d | 2026-10-19 | 2026-10-23 | 192 | 24d |  | LOT 2 | 35h | 4.1.5&4.1.7&4.1.10 |
| 202 | 1.6.28 | F&P équipements CFO |  | 5d | 2026-10-19 | 2026-10-23 | 192 | 0d |  | LOT 2 | 35h | 3.8.2;3.7 |
| 203 | 1.6.29 | Intégration GTC |  | 2d | 2026-10-26 | 2026-10-27 | 202 | 22d |  | LOT 2 | 14h | 2.8.7 |
| 204 | 1.6.30 | F&P système d'alarme |  | 2d | 2026-10-19 | 2026-10-20 | 192 | 27d |  | LOT 4 | 14h | 2.4.4 |
| 205 | 1.6.31 | F&P réseaux secondaire en faux plafond et raccordement aux réseaux posés en phase 1 et 2 |  | 2d | 2026-10-19 | 2026-10-20 | 192 | 26d | 0d | LOT 4 | 14h | 2.4.7 |
| 206 | 1.6.32 | F&P vannes de sectionnement en limite de zone chantier phase 3 |  | 1d | 2026-10-19 | 2026-10-19 | 192 | 28d |  | LOT 4 | 7h | 2.4.6 |
| 207 | 1.6.33 | Essais mise en service et intégration GTC |  | 1d | 2026-10-21 | 2026-10-21 | 205 | 26d |  | LOT 4 | 7h | 2.4.13&2.4.12 |
| 208 | 1.6.34 | Ragréage toutes zones |  | 1d | 2026-10-26 | 2026-10-26 | 202 | 0d |  | LOT 1.5 | 7h | 1.2.2 |
| 209 | 1.6.35 | F&P sol souple toutes zones |  | 2d | 2026-10-27 | 2026-10-28 | 208 | 0d |  | LOT 1.5 | 14h | 1.3 |
| 210 | 1.6.36 | F&P protection type décochoc |  | 2d | 2026-10-29 | 2026-10-30 | 209 | 0d |  | LOT 1.4 | 14h | 1.7.1 |
| 211 | 1.6.37 | Nettoyage phase 1 |  | 1d | 2026-11-02 | 2026-11-02 | 210 | 0d |  | LOT 1.5 | 7h | 2.5 |
| 212 | 1.6.38 | OPR |  | 1d | 2026-11-03 | 2026-11-03 | 211 | 0d |  | ATMOE; MOA | 14h |  |
| 213 | 1.6.39 | Levée des réserves |  | 1d | 2026-11-04 | 2026-11-04 | 212 | 0d |  | LOT 1.1; LOT 1.2; LOT 1.3; LOT 1.4; LOT 1.5; LOT 1.6; LOT 2; LOT 3; LOT 4 | 63h |  |
| 214 | 1.6.40 | Nettoyage phase 2 |  | 1d | 2026-11-05 | 2026-11-05 | 213 | 0d |  | LOT 1.5 | 7h | 2.5 |
| 215 | 1.6.41 | Réception | milestone | 0d | 2026-11-05 | 2026-11-05 | 214 | 0d |  | LOT 1.1; LOT 1.2; LOT 1.3; LOT 1.4 |  |  |
| 216 | 1.6.42 | Bionettoyage |  | 2d | 2026-11-06 | 2026-11-09 | 215 | 12d | 0d | MOA | 14h |  |
| 217 | 1.6.43 | Déménagement & libération emprise phase 2 |  | 1d | 2026-11-10 | 2026-11-10 | 216 | 12d |  | MOA | 7h |  |
| 218 | 1.7 | Fourniture DOE | milestone | 0d | 2026-11-26 | 2026-11-26 | 215FS+15d | 0d |  | LOT 1.1; LOT 1.2; LOT 1.3; LOT 1.4; LOT 1.5; LOT 1.6; LOT 2; LOT 3; LOT 4 |  |  |
